# Chapter3_2011

How a schedule from MS Project changed from version to version. A marks actual dates.

## Version 1 (saved 2011-02-16, file Chapter3_2011_20110919.mpp)

| ID | Task | Duration | Start | Finish | Predecessors | Total float |
| --- | --- | --- | --- | --- | --- | --- |
| 1 | Clear Site | 2d | 2012-03-05 | 2012-03-06 |  | 0d |
| 2 | Building Layout | 1d | 2012-03-07 | 2012-03-07 | 1 | 0d |
| 3 | Form Slab | 2d | 2012-03-08 | 2012-03-09 | 2 | 0d |
| 4 | Under Slab Plumbing | 1d | 2012-03-12 | 2012-03-12 | 3 | 0d |
| 5 | Prepare Slab for Pour | 3d | 2012-03-13 | 2012-03-15 | 4 | 0d |
| 6 | Inspect Slab | 0d | 2012-03-15 | 2012-03-15 | 5 | 0d |
| 7 | Pour Slab | 1d | 2012-03-16 | 2012-03-16 | 6 | 0d |
| 8 | Rough Frame Walls | 2d | 2012-03-19 | 2012-03-20 | 7 | 0d |
| 9 | Rough Frame Roof | 1d? | 2012-03-21 | 2012-03-21 | 8 | 0d |
| 10 | Install Doors and Windows | 0.4d? | 2012-03-22 | 2012-03-22 | 9 | 3.6d |
| 11 | Install Wall Insulation | 1d? | 2012-03-22 | 2012-03-22 | 9 | 0d |
| 12 | Rough Plumbing | 1d? | 2012-03-22 | 2012-03-22 | 9 | 3d |
| 13 | Rough HVAC | 1d? | 2012-03-22 | 2012-03-22 | 9 | 3d |
| 14 | Rough Electrical | 1d? | 2012-03-22 | 2012-03-22 | 9 | 3d |
| 15 | Install Shingles | 1d? | 2012-03-22 | 2012-03-22 | 9 | 0.6d |
| 16 | Exterior Finish Carpentry | 0.4d? | 2012-03-23 | 2012-03-23 | 15 | 0.6d |
| 17 | Hang Drywall | 1d? | 2012-03-23 | 2012-03-23 | 11 | 0d |
| 18 | Finish Drywall | 1d? | 2012-03-26 | 2012-03-26 | 17 | 0d |
| 19 | Place Exterior Brick | 1d? | 2012-03-23 | 2012-03-26 | 16 | 0.6d |
| 20 | Place Cabinets | 1d? | 2012-03-27 | 2012-03-27 | 18 | 0d |
| 21 | Exterior Paint | 1d? | 2012-03-26 | 2012-03-27 | 19 | 0.6d |
| 22 | Interior Finish Carpentry | 0.4d? | 2012-03-05 | 2012-03-05 |  | 16.6d |

## Version 2 (data date 2012-03-16, saved 2011-03-11, file Chapter4_2011_20110919.mpp)

Last finish 2012-03-27 → 2012-03-29 (+2d). Complete tasks 0 → 1.

Changed:

| ID | Task | Start | Finish | Duration | Complete | Total float | Other |
| --- | --- | --- | --- | --- | --- | --- | --- |
| 1 | Clear Site | 2012-03-05 A | 2012-03-06 A |  | 0% → 100% | 0d → none | baseline start 2001-01-08 → 2012-03-05; baseline finish 2001-01-09 → 2012-03-06 |
| 2 | Building Layout | 2012-03-07 A | 2012-03-07 → 2012-03-09 (+2d) | 1d → 3d | 0% → 67% | 0d → 2d | baseline start 2001-01-10 → 2012-03-07; baseline finish 2001-01-10 → 2012-03-07 |
| 3 | Form Slab | 2012-03-08 → 2012-03-12 (+4d) | 2012-03-09 → 2012-03-13 (+4d) |  |  | 0d → 2d | baseline start 2001-01-11 → 2012-03-08; baseline finish 2001-01-12 → 2012-03-09 |
| 4 | Under Slab Plumbing | 2012-03-12 → 2012-03-14 (+2d) | 2012-03-12 → 2012-03-14 (+2d) |  |  | 0d → 2d | baseline start 2001-01-11 → 2012-03-12; baseline finish 2001-01-11 → 2012-03-12 |
| 5 | Prepare Slab for Pour | 2012-03-13 → 2012-03-15 A (+2d) | 2012-03-15 → 2012-03-19 (+4d) |  | 0% → 67% |  | baseline start 2001-01-12 → 2012-03-13; baseline finish 2001-01-16 → 2012-03-15 |
| 6 | Inspect Slab | 2012-03-15 → 2012-03-19 (+4d) | 2012-03-15 → 2012-03-19 (+4d) |  |  |  | baseline start none → 2012-03-15; baseline finish none → 2012-03-15 |
| 7 | Pour Slab | 2012-03-16 → 2012-03-20 (+4d) | 2012-03-16 → 2012-03-20 (+4d) |  |  |  | baseline start 2001-01-17 → 2012-03-16; baseline finish 2001-01-17 → 2012-03-16 |
| 8 | Rough Frame Walls | 2012-03-19 → 2012-03-21 (+2d) | 2012-03-20 → 2012-03-22 (+2d) |  |  |  | baseline start 2001-01-18 → 2012-03-19; baseline finish 2001-01-24 → 2012-03-20 |
| 9 | Rough Frame Roof | 2012-03-21 → 2012-03-23 (+2d) | 2012-03-21 → 2012-03-23 (+2d) |  |  |  | baseline start none → 2012-03-21; baseline finish none → 2012-03-21 |
| 10 | Install Doors and Windows | 2012-03-22 → 2012-03-26 (+4d) | 2012-03-22 → 2012-03-26 (+4d) |  |  |  | baseline start none → 2012-03-22; baseline finish none → 2012-03-22 |
| 11 | Install Wall Insulation | 2012-03-22 → 2012-03-26 (+4d) | 2012-03-22 → 2012-03-26 (+4d) |  |  |  | baseline start none → 2012-03-22; baseline finish none → 2012-03-22 |
| 12 | Rough Plumbing | 2012-03-22 → 2012-03-26 (+4d) | 2012-03-22 → 2012-03-26 (+4d) |  |  |  | baseline start none → 2012-03-22; baseline finish none → 2012-03-22 |
| 13 | Rough HVAC | 2012-03-22 → 2012-03-26 (+4d) | 2012-03-22 → 2012-03-26 (+4d) |  |  |  | baseline start none → 2012-03-22; baseline finish none → 2012-03-22 |
| 14 | Rough Electrical | 2012-03-22 → 2012-03-26 (+4d) | 2012-03-22 → 2012-03-26 (+4d) |  |  |  | baseline start none → 2012-03-22; baseline finish none → 2012-03-22 |
| 15 | Install Shingles | 2012-03-22 → 2012-03-26 (+4d) | 2012-03-22 → 2012-03-26 (+4d) |  |  |  | baseline start none → 2012-03-22; baseline finish none → 2012-03-22 |
| 16 | Exterior Finish Carpentry | 2012-03-23 → 2012-03-27 (+4d) | 2012-03-23 → 2012-03-27 (+4d) |  |  |  | baseline start none → 2012-03-23; baseline finish none → 2012-03-23 |
| 17 | Hang Drywall | 2012-03-23 → 2012-03-27 (+4d) | 2012-03-23 → 2012-03-27 (+4d) |  |  |  | baseline start none → 2012-03-23; baseline finish none → 2012-03-23 |
| 18 | Finish Drywall | 2012-03-26 → 2012-03-28 (+2d) | 2012-03-26 → 2012-03-28 (+2d) |  |  |  | baseline start none → 2012-03-26; baseline finish none → 2012-03-26 |
| 19 | Place Exterior Brick | 2012-03-23 → 2012-03-27 (+4d) | 2012-03-26 → 2012-03-28 (+2d) |  |  |  | baseline start none → 2012-03-23; baseline finish none → 2012-03-26 |
| 20 | Place Cabinets | 2012-03-27 → 2012-03-29 (+2d) | 2012-03-27 → 2012-03-29 (+2d) |  |  |  | baseline start none → 2012-03-27; baseline finish none → 2012-03-27 |
| 21 | Exterior Paint | 2012-03-26 → 2012-03-28 (+2d) | 2012-03-27 → 2012-03-29 (+2d) |  |  |  | baseline start none → 2012-03-26; baseline finish none → 2012-03-27 |
| 22 | Interior Finish Carpentry |  |  |  |  | 16.6d → 17.6d | baseline start none → 2012-03-05; baseline finish none → 2012-03-05 |

## Version 3 (data date 2012-03-16, saved 2011-03-15, file Chapter5_2011_20110919.mpp)

Last finish 2012-03-29 → 2012-04-30 (+32d).

Added:

| ID | Task | Duration | Start | Finish | Predecessors | Resources |
| --- | --- | --- | --- | --- | --- | --- |
| 13 | Rough Elec | 3d | 2012-03-29 | 2012-04-02 | 8 | Sub - Elec [200%] |
| 22 | Interior Finish Paint | 3d | 2012-04-20 | 2012-04-24 | 23, 24, 25, 20, 19 | Painter [300%] |
| 23 | Interior Finish Plumbing | 2d | 2012-04-18 | 2012-04-19 | 21 | Sub - Plbg [200%] |
| 24 | Interior Finish HVAC | 2d | 2012-04-18 | 2012-04-19 | 21 | Sub - HVAC [200%] |
| 25 | Interior Finish Elec | 2d | 2012-04-18 | 2012-04-19 | 21 | Sub - Elec [200%] |
| 26 | Flooring | 2d | 2012-04-25 | 2012-04-26 | 22 | Sub - Flooring [200%] |
| 27 | Prepare Driveways and Walks | 4d | 2012-03-16 | 2012-03-21 | 5 | Carpenter - Cl1; Laborer [200%] |
| 28 | Pour Driveways and Walks | 1d | 2012-03-22 | 2012-03-22 | 27 | Concrete Finisher [200%]; Laborer [300%] |
| 29 | Punch List | 2d | 2012-04-27 | 2012-04-30 | 28, 26 | Carpenter - Cl1; Painter; Sub - Elec; Sub - HVAC; Sub - Plbg |

Removed: 6 Inspect Slab; 14 Rough Electrical

Changed:

| ID | Task | Start | Finish | Duration | Complete | Total float | Predecessors | Other |
| --- | --- | --- | --- | --- | --- | --- | --- | --- |
| 1 | Clear Site |  |  |  |  |  |  | resources none → Carpenter - Cl1; Laborer [200%]; Pickup; Dozer; baseline start 2012-03-05 → 2001-01-08; baseline finish 2012-03-06 → 2001-01-09 |
| 2 | Building Layout |  |  |  |  | 2d → 1.98d |  | resources none → Carpenter - Cl1; Laborer [200%]; baseline start 2012-03-07 → 2001-01-10; baseline finish 2012-03-07 → 2001-01-10 |
| 3 | Form Slab |  |  |  |  |  |  | resources none → Carpenter - Cl1 [200%]; Laborer [200%]; baseline start 2012-03-08 → 2001-01-11; baseline finish 2012-03-09 → 2001-01-12 |
| 4 | Under Slab Plumbing | 2012-03-14 → 2012-03-12 (-2d) | 2012-03-14 → 2012-03-12 (-2d) |  |  | 2d → 1.98d | 3 → 2 | resources none → Sub - Plbg [200%]; baseline start 2012-03-12 → 2001-01-11; baseline finish 2012-03-12 → 2001-01-11 |
| 5 | Prepare Slab for Pour | 2012-03-15 A → 2012-03-13 A (-2d) | 2012-03-19 → 2012-03-15 (-4d) |  | 67% → 66% |  |  | resources none → Carpenter - Cl1; Laborer [200%]; baseline start 2012-03-13 → 2001-01-12; baseline finish 2012-03-15 → 2001-01-16 |
| 6 | Pour Slab | 2012-03-20 → 2012-03-16 (-4d) | 2012-03-20 → 2012-03-16 (-4d) |  |  |  | Inspect Slab → 3, 5 | resources none → Concrete Finisher [200%]; Laborer [300%]; baseline start 2012-03-16 → 2001-01-17; baseline finish 2012-03-16 → 2001-01-17 |
| 7 | Rough Frame Walls | 2012-03-21 → 2012-03-19 (-2d) | 2012-03-22 → 2012-03-23 (+1d) | 2d → 5d |  |  |  | resources Carpenter - CL1 [300%]; Carpenter - CL2 [300%]; Laborer [300%] → Carpenter - Cl1 [300%]; Carpenter - CL2 [300%]; Laborer [300%]; baseline start 2012-03-19 → 2001-01-18; baseline finish 2012-03-20 → 2001-01-24 |
| 8 | Rough Frame Roof | 2012-03-23 → 2012-03-26 (+3d) | 2012-03-23 → 2012-03-28 (+5d) | 1d? → 3d |  |  |  | resources none → Carpenter - Cl1 [300%]; Carpenter - CL2 [300%]; Laborer [300%]; baseline start 2012-03-21 → 2001-01-25; baseline finish 2012-03-21 → 2001-01-29 |
| 9 | Install Doors and Windows |  | 2012-03-26 → 2012-03-27 (+1d) | 0.4d? → 2d |  | 3.6d → 24d | 8 → 7 | resources Carpenter - CL1 [200%]; Laborer [300%] → Carpenter - Cl1 [200%]; Laborer [300%]; baseline start 2012-03-22 → 2001-01-25; baseline finish 2012-03-22 → 2001-01-26 |
| 10 | Install Wall Insulation | 2012-03-26 → 2012-04-03 (+8d) | 2012-03-26 → 2012-04-04 (+9d) | 1d? → 2d |  |  | 8 → 8, 11, 13 | resources none → Carpenter - Cl1 [200%]; Laborer [300%]; baseline start 2012-03-22 → 2001-02-02; baseline finish 2012-03-22 → 2001-02-05 |
| 11 | Rough Plumbing | 2012-03-26 → 2012-03-29 (+3d) | 2012-03-26 → 2012-04-02 (+7d) | 1d? → 3d |  | 3d → 0d |  | resources none → Sub - Plbg [200%]; baseline start 2012-03-22 → 2001-01-30; baseline finish 2012-03-22 → 2001-02-01 |
| 12 | Rough HVAC | 2012-03-26 → 2012-03-29 (+3d) | 2012-03-26 → 2012-03-30 (+4d) | 1d? → 2d |  |  |  | resources none → Sub - HVAC [200%]; baseline start 2012-03-22 → 2001-01-30; baseline finish 2012-03-22 → 2001-01-31 |
| 14 | Install Shingles | 2012-03-26 → 2012-03-29 (+3d) | 2012-03-26 → 2012-03-30 (+4d) | 1d? → 2d |  | 0.6d → 3d |  | resources none → Carpenter - Cl1 [200%]; Laborer [300%]; baseline start 2012-03-22 → 2001-01-30; baseline finish 2012-03-22 → 2001-01-31 |
| 15 | Exterior Finish Carpentry | 2012-03-27 → 2012-04-05 (+9d) | 2012-03-27 → 2012-04-10 (+14d) | 0.4d? → 4d |  | 0.6d → 0d | 14 → 10, 14 | resources Carpenter - CL1 [200%]; Laborer [300%] → Carpenter - Cl1 [200%]; Laborer [300%]; baseline start 2012-03-23 → 2001-02-06; baseline finish 2012-03-23 → 2001-02-09 |
| 16 | Hang Drywall | 2012-03-27 → 2012-04-05 (+9d) | 2012-03-27 → 2012-04-09 (+13d) | 1d? → 3d |  |  | 10 → 10, 12 | resources none → Carpenter - Cl1; Laborer [200%]; baseline start 2012-03-23 → 2001-02-06; baseline finish 2012-03-23 → 2001-02-08 |
| 17 | Finish Drywall | 2012-03-28 → 2012-04-10 (+13d) | 2012-03-28 → 2012-04-12 (+15d) | 1d? → 3d |  |  |  | resources none → Drywall Finisher [200%]; baseline start 2012-03-26 → 2001-02-09; baseline finish 2012-03-26 → 2001-02-13 |
| 18 | Place Exterior Brick | 2012-03-27 → 2012-04-11 (+15d) | 2012-03-28 → 2012-04-16 (+19d) | 1d? → 4d |  | 0.6d → 0d |  | resources none → Mason [200%]; Mixer; Laborer [200%]; baseline start 2012-03-23 → 2001-02-12; baseline finish 2012-03-26 → 2001-02-15 |
| 19 | Place Cabinets | 2012-03-29 → 2012-04-13 (+15d) | 2012-03-29 → 2012-04-13 (+15d) | 1d? → 1d |  | 0d → 4d |  | resources none → Carpenter - Cl1; Carpenter - CL2; baseline start 2012-03-27 → 2001-02-14; baseline finish 2012-03-27 → 2001-02-14 |
| 20 | Exterior Paint | 2012-03-28 → 2012-04-17 (+20d) | 2012-03-29 → 2012-04-19 (+21d) | 1d? → 3d |  | 0.6d → 0d | 18 → 15, 18 | resources none → Painter [300%]; baseline start 2012-03-26 → 2001-02-16; baseline finish 2012-03-27 → 2001-02-20 |
| 21 | Interior Finish Carpentry | 2012-03-05 → 2012-04-13 (+39d) | 2012-03-05 → 2012-04-17 (+43d) | 0.4d? → 3d |  | 17.6d → 0d | none → 17 | resources Carpenter - CL1 [200%]; Laborer [300%] → Carpenter - Cl1 [200%]; Laborer [300%]; baseline start 2012-03-05 → 2001-02-14; baseline finish 2012-03-05 → 2001-02-16 |
